# System Implementation

Schedule from MS Project, 2022-12-01 to 2023-04-06, costs in $, A marks actual dates.
Rank Group

## Calendars

- System Implementation: Mon-Fri 08:00-12:00, 13:00-17:00; Sat-Sun off. Exceptions (off unless hours are given): 2022-12-26 (Holiday), 2023-01-02 (Holiday).

## Resources

| Resource | Unit | Rate |
| --- | --- | --- |
| Maryann Melendez |  | 50 |
| Ray Cotter |  | 60 |
| Len Hu |  | 60 |
| Deepak Prasad |  | 75 |
| June Davis |  | 75 |
| Cam Jones |  | 60 |
| USB Flash Drives | 5 Pack | 19.99 |

## Schedule

| ID | WBS | Task | Type | Duration | Start | Finish | Predecessors | Complete | Remaining | Baseline start | Baseline finish | Baseline duration | Total slack | Resources | Work | Actual work | Cost | Baseline cost | Actual cost |
| --- | --- | --- | --- | --- | --- | --- | --- | --- | --- | --- | --- | --- | --- | --- | --- | --- | --- | --- | --- |
| 1 | 1 | **Groundwork** |  | 12.5d | 2022-12-01 A | 2022-12-19 A |  | 100% |  | 2022-12-01 | 2022-12-16 | 11.5d |  |  | 232h | 232h | 14,800 | 14,800 | 14,800 |
| 2 | 1.1 | Identify affected departments |  | 1w | 2022-12-01 A | 2022-12-07 A |  | 100% |  | 2022-12-01 | 2022-12-07 | 1w |  | Maryann Melendez; Len Hu | 80h | 80h | 4,400 | 4,400 | 4,400 |
| 3 | 1.2 | Identify department representatives |  | 1d | 2022-12-09 A | 2022-12-09 A | 2 | 100% |  | 2022-12-08 | 2022-12-08 | 1d |  | Ray Cotter | 8h | 8h | 480 | 480 | 480 |
| 4 | 1.3 | Planning meeting to discuss requirements |  | 4h | 2022-12-12 A | 2022-12-12 A | 3 | 100% |  | 2022-12-09 | 2022-12-09 | 4h |  | Ray Cotter; Maryann Melendez; Len Hu; June Davis; Deepak Prasad; Cam Jones | 24h | 24h | 1,520 | 1,520 | 1,520 |
| 5 | 1.4 | Develop initial budget |  | 1w | 2022-12-12 A | 2022-12-19 A | 4 | 100% |  | 2022-12-09 | 2022-12-16 | 1w |  | Deepak Prasad; June Davis; Cam Jones | 120h | 120h | 8,400 | 8,400 | 8,400 |
| 6 | 2 | **Selection** |  | 20.75d | 2022-12-19 A | 2023-01-19 |  | 17% | 17.25d | 2022-12-16 | 2023-01-18 | 20.75d | 0d |  | 192h | 7h | 13,860 | 13,860 | 420 |
| 7 | 2.1 | Review existing workflow and software |  | 2w | 2022-12-19 A | 2023-01-04 | 5 | 35% | 1.3w | 2022-12-16 | 2023-01-03 | 2w | 0d | Ray Cotter [25%] | 20h | 7h | 1,200 | 1,200 | 420 |
| 8 | 2.2 | Indentify systems (software and hardware) and vendors |  | 2w | 2023-01-04 | 2023-01-18 | 7 |  |  | 2023-01-03 | 2023-01-17 | 2w | 0d | Deepak Prasad; June Davis | 160h |  | 12,000 | 12,000 |  |
| 9 | 2.3 | Review proposals |  | 6h | 2023-01-18 | 2023-01-19 | 8 |  |  | 2023-01-17 | 2023-01-18 | 6h | 0d | Len Hu; Maryann Melendez | 12h |  | 660 | 660 |  |
| 10 | 2.4 | Selection solution and vendor | milestone | 0d | 2023-01-19 | 2023-01-19 | 9 |  |  | 2023-01-18 | 2023-01-18 | 0d | 0d |  |  |  |  |  |  |
| 11 | 3 | **Planning** |  | 11.75d | 2023-01-19 | 2023-02-03 |  |  |  | 2023-01-18 | 2023-02-02 | 11.75d | 0d |  | 218h |  | 13,600 | 13,600 |  |
| 12 | 3.1 | White board workflow changes |  | 1d | 2023-01-19 | 2023-01-20 | 10 |  |  | 2023-01-18 | 2023-01-19 | 1d | 0d | Len Hu; Maryann Melendez; Cam Jones; Deepak Prasad; June Davis; Ray Cotter | 48h |  | 3,040 | 3,040 |  |
| 13 | 3.2 | Role play new workflow |  | 3d | 2023-01-20 | 2023-01-25 | 12 |  |  | 2023-01-19 | 2023-01-24 | 3d | 0d | Cam Jones; June Davis | 48h |  | 3,240 | 3,240 |  |
| 14 | 3.3 | Refine new workflow |  | 2d | 2023-01-25 | 2023-01-27 | 13 |  |  | 2023-01-24 | 2023-01-26 | 2d | 0d | Deepak Prasad; Cam Jones | 32h |  | 2,160 | 2,160 |  |
| 15 | 3.4 | Develop implementation schedule |  | 0.5w | 2023-01-27 | 2023-01-31 | 14 |  |  | 2023-01-26 | 2023-01-30 | 0.5w | 0d | Ray Cotter; Cam Jones | 40h |  | 2,400 | 2,400 |  |
| 16 | 3.5 | Provide implementation plan to department representatives |  | 2h | 2023-01-31 | 2023-01-31 | 15 |  |  | 2023-01-30 | 2023-01-30 | 2h | 0d | Ray Cotter | 2h |  | 120 | 120 |  |
| 17 | 3.6 | Resolve open issues or questions |  | 3d | 2023-02-01 | 2023-02-03 | 16 |  |  | 2023-01-31 | 2023-02-02 | 3d | 0d | Ray Cotter; Maryann Melendez | 48h |  | 2,640 | 2,640 |  |
| 18 | 4 | **Documentation** |  | 30d | 2023-02-06 | 2023-03-17 |  |  |  | 2023-02-03 | 2023-03-16 | 30d | 0d |  | 416h |  | 25,199.88 | 25,199.88 |  |
| 19 | 4.1 | Develop workflow and software instructions |  | 2w | 2023-02-06 | 2023-02-17 | 17 |  |  | 2023-02-03 | 2023-02-16 | 2w | 0d | Ray Cotter; Len Hu | 160h |  | 9,600 | 9,600 |  |
| 20 | 4.2 | Establish training schedule |  | 2d | 2023-02-20 | 2023-02-21 | 19 |  |  | 2023-02-17 | 2023-02-20 | 2d | 0d | Ray Cotter | 16h |  | 960 | 960 |  |
| 21 | 4.3 | Perform employee training |  | 3w | 2023-02-27 | 2023-03-17 | 20FS+3d |  |  | 2023-02-24 | 2023-03-16 | 3w | 0d | Ray Cotter; Len Hu; USB Flash Drives [12 5 Pack] | 240h |  | 14,639.88 | 14,639.88 |  |
| 22 | 5 | **Launch** |  | 13.5d | 2023-03-20 | 2023-04-06 |  |  |  | 2023-03-17 | 2023-04-05 | 13.5d | 0d |  | 476h |  | 32,240 | 32,240 |  |
| 23 | 5.1 | Back up systems and data |  | 2d | 2023-03-20 | 2023-03-21 | 21 |  |  | 2023-03-17 | 2023-03-20 | 2d | 0d | Deepak Prasad; June Davis | 32h |  | 2,400 | 2,400 |  |
| 24 | 5.2 | Setup and install |  | 1w | 2023-03-22 | 2023-03-28 | 23 |  |  | 2023-03-21 | 2023-03-27 | 1w | 0d | Deepak Prasad; June Davis | 80h |  | 6,000 | 6,000 |  |
| 25 | 5.3 | Go live |  | 4h | 2023-03-29 | 2023-03-29 | 24 |  |  | 2023-03-28 | 2023-03-28 | 4h | 0d | Cam Jones | 4h |  | 240 | 240 |  |
| 26 | 5.4 | Optimize and troubleshoot |  | 1w | 2023-03-29 | 2023-04-05 | 25 |  |  | 2023-03-28 | 2023-04-04 | 1w | 0d | Deepak Prasad; June Davis; Cam Jones | 120h |  | 8,400 | 8,400 |  |
| 27 | 5.5 | Peformance and budget audit |  | 1w | 2023-03-30 | 2023-04-06 | 26FF+1d |  |  | 2023-03-29 | 2023-04-05 | 1w | 0d | Deepak Prasad; June Davis; Cam Jones; Maryann Melendez; Ray Cotter; Len Hu | 240h |  | 15,200 | 15,200 |  |
| 28 | 5.6 | Completion | milestone | 0d | 2023-04-06 | 2023-04-06 | 27 |  |  | 2023-04-05 | 2023-04-05 | 0d | 0d |  |  |  |  |  |  |
